# Schedule

Schedule from MS Project, 2011-01-03 to 2012-09-25.
MBARI

## Calendars

- Standard: Mon-Fri 08:00-12:00, 13:00-17:00; Sat-Sun off.

## Schedule

| ID | WBS | Task | Duration | Start | Finish | Predecessors | Total slack | Free slack | Constraint |
| --- | --- | --- | --- | --- | --- | --- | --- | --- | --- |
| 3 | 1 | Electrical Gen. at-sea test | 5d? | 2011-11-07 | 2011-11-11 |  | 188d |  | finish no earlier than 2011-11-11 |
| 4 | 2 | Electrical Gen. at-sea re-test | 5d? | 2011-12-12 | 2011-12-16 |  | 163d |  | finish no earlier than 2011-12-16 |
| 9 | 3 | Power Converter Design, build and test | 197d? | 2011-06-01 | 2012-03-01 |  | 109d |  | start no earlier than 2011-06-01 |
| 10 | 4 | Prototype Board in Layout | 8d? | 2011-11-14 | 2011-11-23 |  | 169d | 11d | finish no earlier than 2011-11-23 |
| 11 | 5 | Prototype Board Build | 3d? | 2011-12-09 | 2011-12-13 | 10 | 158d | 0d | start no earlier than 2011-12-09 |
| 12 | 6 | Prototype Lab Testing | 8d? | 2011-12-14 | 2011-12-23 | 11 | 158d |  | start no earlier than 2011-12-14 |
| 13 | 7 | Implement necessary redesign | 11d? | 2012-01-02 | 2012-01-16 |  | 142d |  | finish no earlier than 2012-01-16 |
| 14 | 8 | Board Re-layout | 7d? | 2012-01-16 | 2012-01-24 |  | 136d |  | start no earlier than 2012-01-16 |
| 15 | 9 | Prototype Board Build | 5d? | 2012-02-06 | 2012-02-10 |  | 123d |  | finish no earlier than 2012-02-10 |
| 16 | 10 | Final Lab Testing | 10d? | 2012-02-13 | 2012-02-24 |  | 113d |  | finish no earlier than 2012-02-24 |
| 19 | 11 | System Control Enhancements | 153d? | 2012-01-02 | 2012-08-01 |  | 39d |  | start no earlier than 2012-01-02 |
| 22 | 12 | Dock Stabilization Tests | 191d? | 2011-06-01 | 2012-02-22 |  | 115d |  | finish no earlier than 2012-02-22 |
| 23 | 13 | Redesign for electrical pass-through | 10d? | 2012-01-02 | 2012-01-13 |  | 143d |  | finish no earlier than 2012-01-13 |
| 24 | 14 | Procure needed components | 26d? | 2012-01-02 | 2012-02-06 |  | 127d |  | finish no earlier than 2012-02-06 |
| 25 | 15 | Integrate and lab test | 9d? | 2012-02-07 | 2012-02-17 |  | 118d |  | finish no earlier than 2012-02-17 |
| 26 | 16 | At sea test | 5d? | 2012-02-20 | 2012-02-24 |  | 113d |  | finish no earlier than 2012-02-24 |
| 29 | 17 | AUV Homing Tests | 140d? | 2011-05-02 | 2011-11-11 |  | 188d |  | start no earlier than 2011-05-02 |
| 30 | 18 | USBL Integration | 117d? | 2011-05-02 | 2011-10-11 |  | 211d |  | finish no earlier than 2011-10-11 |
| 31 | 19 | Software Implementation | 49d? | 2011-09-05 | 2011-11-10 |  | 188d | 0d | finish no earlier than 2011-11-10 |
| 32 | 20 | At-Sea Tests | 1d? | 2011-11-11 | 2011-11-11 | 31 | 188d |  | start no earlier than 2011-11-11 |
| 34 | 21 | Mock Dock Tests | 126d? | 2011-07-01 | 2011-12-23 |  | 197d |  | start no earlier than 2011-07-01 |
| 35 | 22 | Mock Dock Design and Build | 116d? | 2011-07-01 | 2011-12-09 |  | 207d |  | start no earlier than 2011-07-01 |
| 36 | 23 | Mock Dock Deployment | 5d? | 2011-12-12 | 2011-12-16 |  | 202d |  | start no earlier than 2011-12-12 |
| 37 | 24 | At-Sea Testing | 10d? | 2011-12-19 | 2011-12-30 |  | 192d |  | finish no earlier than 2011-12-30 |
| 39 | 25 | AUV Dock Design and Fabrication | 303d? | 2011-01-03 | 2012-02-29 |  | 149d |  | start no earlier than 2011-01-03 |
| 40 | 26 | Concept Development | 108d? | 2011-01-03 | 2011-06-01 |  | 150d | 0d | finish no earlier than 2011-06-01 |
| 41 | 27 | Concept Design Review | 1d? | 2011-06-02 | 2011-06-02 | 40 | 150d | 0d |  |
| 42 | 28 | Design work | 92d? | 2011-06-03 | 2011-10-10 | 41 | 150d | 0d | start no earlier than 2011-06-03 |
| 43 | 29 | Prelimiminary Design Review | 1d? | 2011-10-11 | 2011-10-11 | 42 | 150d | 0d | start no earlier than 2011-10-11 |
| 44 | 30 | Detailed Design Work | 38d? | 2011-10-12 | 2011-12-02 | 43 | 150d | 0d | start no earlier than 2011-10-12 |
| 45 | 31 | Critical Design Review | 1d? | 2011-12-05 | 2011-12-05 | 44 | 150d | 1d |  |
| 46 | 32 | Dock Fabrication | 40d? | 2011-12-07 | 2012-01-31 | 45 | 149d | 0d | finish no earlier than 2012-01-31 |
| 47 | 33 | Lab Integration and Test | 21d? | 2012-02-01 | 2012-02-29 | 46 | 149d |  | start no earlier than 2012-02-01 |
| 50 | 34 | AUV Dock Test to Stationary Mooring | 10d? | 2012-03-05 | 2012-03-16 |  | 137d |  | finish no earlier than 2012-03-16 |
| 53 | 35 | AUV Dock test to wave-energy buoy | 5d? | 2012-04-09 | 2012-04-13 |  | 117d |  | finish no earlier than 2012-04-13 |
| 56 | 36 | Two-Week Demonstration Deployment | 11d? | 2012-07-02 | 2012-07-16 |  | 51d |  | finish no earlier than 2012-07-16 |
| 60 | 37 | Final Report Writing | 25d? | 2012-08-22 | 2012-09-25 |  | 0d |  | finish no earlier than 2012-09-25 |
